Schedule from Planner, 2015-01-30 to 2015-02-12.

## Calendars

- Predeterminado: Mon-Fri 08:00-12:00, 13:00-17:00; Sat-Sun off.

## Schedule

| ID | WBS | Task | Start | Finish | Predecessors | Work |
| --- | --- | --- | --- | --- | --- | --- |
| 1 | 1 | **Expresiones array** | 2015-01-30 | 2015-02-12 |  | 80h |
| 2 | 1.1 | **Objetivos** | 2015-01-30 | 2015-01-30 |  | 8h |
| 3 | 1.1.1 | Definir objetivos y alcance | 2015-01-30 | 2015-01-30 |  | 4h |
| 4 | 1.1.2 | Capturar requisitos | 2015-01-30 | 2015-01-30 |  | 4h |
| 5 | 1.2 | **Riesgos** | 2015-01-30 | 2015-02-02 | 4 | 9h |
| 6 | 1.2.1 | Análisis de riesgos | 2015-01-30 | 2015-02-02 |  | 6h |
| 7 | 1.2.2 | Listado de alternativas | 2015-02-02 | 2015-02-02 | 6 | 3h |
| 8 | 1.3 | **Desarrollo** | 2015-02-02 | 2015-02-11 | 7 | 55h |
| 9 | 1.3.1 | **Análisis** | 2015-02-02 | 2015-02-03 |  | 8h |
| 10 | 1.3.1.1 | **Modelo casos de usos** | 2015-02-02 | 2015-02-02 |  | 3h |
| 11 | 1.3.1.1.1 | Diagrma de casos de usos | 2015-02-02 | 2015-02-02 |  | 1h |
| 12 | 1.3.1.1.2 | Descripcion casos de usos | 2015-02-02 | 2015-02-02 | 11 | 2h |
| 13 | 1.3.1.2 | **Modelo copceptual de datos** | 2015-02-03 | 2015-02-03 | 12 | 1h |
| 14 | 1.3.1.2.1 | Diagrama de clases | 2015-02-03 | 2015-02-03 |  | 1h |
| 15 | 1.3.1.3 | **Modelo de comportamiento** | 2015-02-03 | 2015-02-03 | 14 | 4h |
| 16 | 1.3.1.3.1 | Diagrama secuencia | 2015-02-03 | 2015-02-03 |  | 2h |
| 17 | 1.3.1.3.2 | Descripción de contratos | 2015-02-03 | 2015-02-03 | 16 | 2h |
| 18 | 1.3.2 | **Diseño** | 2015-02-03 | 2015-02-04 | 17 | 8h |
| 19 | 1.3.2.1 | Gramática | 2015-02-03 | 2015-02-04 |  | 4h |
| 20 | 1.3.2.2 | **Arquitectura** | 2015-02-04 | 2015-02-04 | 19 | 2h |
| 21 | 1.3.2.2.1 | Diagrama de clases | 2015-02-04 | 2015-02-04 |  | 2h |
| 22 | 1.3.2.3 | **Componentes** | 2015-02-04 | 2015-02-04 | 21 | 2h |
| 23 | 1.3.2.3.1 | Diagrama secuencia | 2015-02-04 | 2015-02-04 |  | 2h |
| 24 | 1.3.3 | **Codificación** | 2015-02-04 | 2015-02-10 | 23 | 34h |
| 25 | 1.3.3.1 | Léxico | 2015-02-04 | 2015-02-04 |  | 1h |
| 26 | 1.3.3.2 | Sintaxis | 2015-02-04 | 2015-02-04 | 25 | 1h |
| 27 | 1.3.3.3 | Semantica | 2015-02-04 | 2015-02-10 | 26 | 32h |

| ID | WBS | Task | Start | Finish | Predecessors | Work |
| --- | --- | --- | --- | --- | --- | --- |
| 28 | 1.3.4 | **Pruebas** | 2015-02-10 | 2015-02-11 | 27 | 5h |
| 29 | 1.3.4.1 | Casos de prueba | 2015-02-10 | 2015-02-11 |  | 2h |
| 30 | 1.3.4.2 | Pruebas unitarias | 2015-02-11 | 2015-02-11 | 29 | 2h |
| 31 | 1.3.4.3 | Verificación | 2015-02-11 | 2015-02-11 | 30 | 1h |
| 32 | 1.4 | **Planificación** | 2015-02-11 | 2015-02-12 | 31 | 8h |
| 33 | 1.4.1 | Revisión de estado y productos | 2015-02-11 | 2015-02-11 |  | 4h |
| 34 | 1.4.2 | Planificación de siguiente iteración | 2015-02-12 | 2015-02-12 | 33 | 4h |
